# Metasepi Project

Schedule from Planner, 2014-01-01 to 2014-10-03.

## Calendars

- デフォルト: Mon-Fri 08:00-12:00, 13:00-17:00; Sat-Sun off.

## Schedule

| ID | WBS | Task | Type | Duration | Start | Finish | Predecessors | Constraint | Work |
| --- | --- | --- | --- | --- | --- | --- | --- | --- | --- |
| 1 | 1 | **Snatch: NetBSD AC'97** |  |  | 2014-01-01 | 2014-05-08 |  |  | 725.75h |
| 2 | 1.1 | 1st try |  |  | 2014-01-01 | 2014-02-21 |  |  | 304h |
| 3 | 1.2 | 2014 Tokyo/Spring | milestone | 0d | 2014-02-28 | 2014-02-28 | 2 | must start on 2014-02-28 |  |
| 4 | 1.3 | Fix outline of paper |  |  | 2014-02-24 | 2014-04-07 | 2 |  | 248h |
| 5 | 1.4 | Benchmark |  |  | 2014-04-08 | 2014-04-09 | 4 |  | 16h |
| 6 | 1.5 | Write paper |  |  | 2014-04-10 | 2014-04-14 | 5 |  | 24h |
| 7 | 1.6 | Cleanup code&paper |  |  | 2014-04-15 | 2014-05-07 | 6 |  | 133.75h |
| 8 | 1.7 | Paper deadline | milestone | 0d | 2014-05-09 | 2014-05-09 | 7 | must start on 2014-05-09 |  |
| 9 | 2 | **Translate ATS doc** |  |  | 2014-04-15 | 2014-06-20 | 6 |  | 392h |
| 10 | 2.1 | INT2PROGINATS |  |  | 2014-04-15 | 2014-05-26 |  |  | 240h |
| 11 | 2.2 | ATS2TUTORIAL |  |  | 2014-05-27 | 2014-06-20 | 10 |  | 152h |
| 12 | 3 | **ATS demo on tiny CPU** |  |  | 2014-05-27 | 2014-07-21 | 10 |  | 320h |
| 13 | 3.1 | ARM support to ATS |  |  | 2014-05-27 | 2014-06-23 |  |  | 160h |
| 14 | 3.2 | AVR support to ATS |  |  | 2014-06-24 | 2014-07-21 | 13 |  | 160h |
| 15 | 4 | OSC@Kansai | milestone | 0d | 2014-08-01 | 2014-08-01 | 14 | must start on 2014-08-01 |  |
| 16 | 5 | ATS Windows installer |  |  | 2014-07-22 | 2014-08-18 | 14 |  | 160h |
| 17 | 6 | **Ready up Functional IoT** |  |  | 2014-08-19 | 2014-10-03 | 16 |  | 272h |
| 18 | 6.1 | Make up ethernet board |  |  | 2014-08-19 | 2014-08-27 |  | start no earlier than 2014-06-01 | 56h |
| 19 | 6.2 | STM32 Ethernet test |  |  | 2014-08-28 | 2014-09-05 | 18 |  | 56h |
| 20 | 6.3 | gdbserver test |  |  | 2014-09-08 | 2014-09-16 | 19 |  | 56h |
| 21 | 6.4 | Write manual |  |  | 2014-09-17 | 2014-10-03 | 20 |  | 104h |
| 22 | 6.5 | Meetup at Nagoya | milestone | 0d | 2014-10-03 | 2014-10-03 | 21 |  |  |
| 23 | 7 | **ATS snatches NetBSD** |  |  | 2014-07-22 | 2014-09-01 | 14 |  | 240h |
| 24 | 7.1 | Setup raspberrypi |  |  | 2014-07-22 | 2014-08-11 |  |  | 120h |
| 25 | 7.2 | Choose snatch target |  |  | 2014-08-12 | 2014-08-25 | 24 |  | 80h |
| 26 | 7.3 | Setup ATS config |  |  | 2014-08-26 | 2014-09-01 | 25 |  | 40h |
