# Metasepi Plan for Chiers/Bohai iteration

Schedule from Planner, 2017-02-01 to 2017-12-28.
Metasepi

## Calendars

- Default: Mon-Fri 08:00-12:00, 13:00-17:00; Sat-Sun off.

## Schedule

| ID | Task | Type | Duration | Start | Finish | Predecessors | Complete | Constraint | Work |
| --- | --- | --- | --- | --- | --- | --- | --- | --- | --- |
| 1 | Survey Meteor |  |  | 2017-02-01 | 2017-02-20 |  |  |  | 108.25h |
| 2 | ChibiOS poster |  |  | 2017-02-20 | 2017-03-01 | 1 |  |  | 56h |
| 3 | c2ats poster |  |  | 2017-03-01 | 2017-03-06 | 2 |  |  | 24h |
| 4 | PPL2017 poster | milestone | 0d | 2017-03-08 | 2017-03-08 | 3 |  | must start on 2017-03-08 |  |
| 5 | Survey GObject Introspection |  |  | 2017-03-06 | 2017-03-22 | 3 |  |  | 96h |
| 6 | GObject Introspection for ATS |  |  | 2017-03-22 | 2017-04-19 | 5 |  |  | 160h |
| 7 | Write paper |  |  | 2017-04-19 | 2017-05-17 | 6 |  |  | 160h |
| 8 | 静的コード解析の会 #2 | milestone | 0d | 2017-05-01 | 2017-04-29 | 6 |  | must start on 2017-04-29 |  |
| 9 | ML Workshop 2017 CFP? | milestone | 0d | 2017-05-18 | 2017-05-18 | 7 |  | must start on 2017-05-18 |  |
| 10 | Survey ATS nodejs package |  |  | 2017-05-17 | 2017-05-24 | 7 |  |  | 40h |
| 11 | Sample Meteor app |  |  | 2017-05-24 | 2017-06-07 | 10 |  |  | 80h |
| 12 | Survey ATS on Japascript |  |  | 2017-06-07 | 2017-06-21 | 11 |  |  | 80h |
| 13 | ATS SPA framework |  |  | 2017-06-21 | 2017-08-02 | 12 |  |  | 240h |
| 14 | Tweet count SPA application |  |  | 2017-08-02 | 2017-09-13 | 13 |  |  | 240h |
| 15 | 静的コード解析の会 #3 @名古屋 | milestone | 0d | 2017-05-29 | 2017-05-28 | 10, 38 |  | must start on 2017-05-28 |  |
| 16 | Translate VeriFast tutorial |  |  | 2017-02-01 | 2017-06-29 |  |  |  | 852h |
| 17 | Deadline of Functional Ikamusume | milestone | 0d | 2017-06-30 | 2017-06-30 | 16 |  | must start on 2017-06-30 |  |
| 18 | Survey NetBSD Rump |  |  | 2017-09-13 | 2017-10-13 | 14 |  |  | 179.75h |
| 19 | Work on FreeRTOS |  |  | 2017-02-01 | 2017-02-28 |  | 100% |  | 160h |
| 20 | Setup FreeRTOS environment | milestone | 0d | 2017-03-01 | 2017-03-01 | 19 |  | must start on 2017-03-01 |  |
| 21 | Secure OS prototype1 |  |  | 2017-03-01 | 2017-04-27 | 19 | 100% |  | 336h |
| 22 | Demo meeting | milestone | 0d | 2017-04-28 | 2017-04-28 | 21 |  | must start on 2017-04-28 |  |
| 23 | Secure OS prototype2 |  |  | 2017-04-28 | 2017-06-23 | 21 | 50% |  | 328h |
| 24 | Choose RTOS for demo |  |  | 2017-06-26 | 2017-07-04 | 23 |  |  | 56h |
| 25 | Write demo spec |  |  | 2017-07-05 | 2017-07-11 | 24 |  |  | 40h |
| 26 | Write requirement |  |  | 2017-07-12 | 2017-07-18 | 25 |  |  | 40h |
| 27 | Create bridge between Client/TA |  |  | 2017-07-19 | 2017-08-08 | 26 |  |  | 120h |
| 28 | Maintain interrupt on TEE |  |  | 2017-08-09 | 2017-08-22 | 27 |  |  | 80h |
| 29 | Watch REE from TEE |  |  | 2017-08-23 | 2017-09-12 | 28 |  |  | 120h |
| 30 | Fix external API |  |  | 2017-09-13 | 2017-09-19 | 29 |  |  | 40h |
| 31 | Fix internal API |  |  | 2017-09-20 | 2017-09-26 | 30 |  |  | 40h |
| 32 | Write test code/doc |  |  | 2017-09-27 | 2017-10-17 | 31 |  |  | 120h |
| 33 | Start to write demo | milestone | 0d | 2017-09-15 | 2017-09-15 |  |  | must start on 2017-09-15 |  |
| 34 | Write demo |  |  | 2017-09-15 | 2017-10-26 | 33 |  |  | 240h |
| 35 | Start to port demo on uFOX | milestone | 0d | 2017-10-16 | 2017-10-16 |  |  | must start on 2017-10-16 |  |
| 36 | Port demo on uFOX |  |  | 2017-10-16 | 2017-12-27 | 35 |  |  | 424h |
| 37 | 1st demo release | milestone | 0d | 2017-12-28 | 2017-12-28 | 36, 41 |  | must start on 2017-12-28 |  |
| 38 | VeriFast on production |  |  | 2017-04-28 | 2017-05-26 | 21 | 50% |  | 168h |
| 39 | Survey clang parser |  |  | 2017-05-29 | 2017-08-04 | 38 | 10% |  | 400h |
| 40 | Survey VeriFast internal |  |  | 2017-08-07 | 2017-09-01 | 39 |  |  | 160h |
| 41 | C99 compat VeriFast |  |  | 2017-09-04 | 2017-12-22 | 40 |  |  | 640h |
